# 援萨摩亚游泳馆工程总体进度计划

Schedule from MS Project, 2004-12-18 to 2005-11-30.
Samsung Electronics

## Calendars

- 标准: Mon-Sun 08:00-12:00, 13:00-17:00.

## Schedule

| ID | WBS | Task | Type | Duration | Start | Finish | Predecessors | Total slack | Free slack |
| --- | --- | --- | --- | --- | --- | --- | --- | --- | --- |
| 1 | 1 | **援萨摩亚游泳馆工程总体进度计划** |  | 348d | 2004-12-18 | 2005-11-30 |  | 0d |  |
| 2 | 1.1 | 开始 | milestone | 0d | 2004-12-18 | 2004-12-18 |  | 0d |  |
| 3 | 1.2 | 场地平整 |  | 5d | 2004-12-18 | 2004-12-22 | 2 | 0d |  |
| 4 | 1.3 | 工程放线 |  | 1d | 2004-12-23 | 2004-12-23 | 3 | 0d |  |
| 5 | 1.4 | 施工准备（暂设、道路） |  | 7d | 2004-12-24 | 2004-12-30 | 4 | 0d |  |
| 6 | 1.5 | 土方开挖 |  | 20d | 2004-12-31 | 2005-01-19 | 5 | 0d |  |
| 7 | 1.6 | 褥垫层 |  | 5d | 2005-01-20 | 2005-01-24 | 6 | 0d |  |
| 8 | 1.7 | 垫层施工 |  | 2d | 2005-01-25 | 2005-01-26 | 7 | 0d |  |
| 9 | 1.6 | 基础承台施工 |  | 12d | 2005-01-27 | 2005-02-07 | 8 | 0d |  |
| 10 | 1.7 | 地下结构施工 |  | 20d | 2005-01-31 | 2005-02-19 | 9FS-8d | 0d |  |
| 11 | 1.8 | 地上结构施工 |  | 60d | 2005-02-20 | 2005-04-20 | 10 | 0d |  |
| 12 | 1.15 | 游泳池结构施工 |  | 30d | 2005-03-07 | 2005-04-05 | 10FS+15d | 22d | 0d |
| 13 | 1.16 | 房心回填（含泳池肥槽） |  | 5d | 2005-05-04 | 2005-05-08 | 12FS+28d | 206d |  |
| 14 | 1.17 | 钢结构施工 |  | 46d | 2005-04-28 | 2005-06-12 | 11FS+7d, 12 | 0d |  |
| 15 | 1.20 | 泳池装修 |  | 60d | 2005-06-13 | 2005-08-11 | 12, 14 | 105d |  |
| 16 | 1.9 | 二次结构 |  | 40d | 2005-04-21 | 2005-05-30 | 11 | 13d |  |
| 17 | 1.10 | 内墙抹灰及水泥地面 |  | 30d | 2005-06-13 | 2005-07-12 | 16, 14 | 0d |  |
| 18 | 1.17 | 吊顶 |  | 25d | 2005-07-13 | 2005-08-06 | 17, 14 | 0d |  |
| 19 | 1.11 | 门窗口安装 |  | 30d | 2005-07-13 | 2005-08-11 | 17 | 86d | 0d |
| 20 | 1.12 | 门扇安装 |  | 25d | 2005-08-12 | 2005-09-05 | 19 | 86d |  |
| 21 | 1.13 | 基础外防水 |  | 5d | 2005-02-20 | 2005-02-24 | 10 | 259d | 0d |
| 22 | 1.14 | 肥槽回填土 |  | 20d | 2005-02-25 | 2005-03-16 | 21 | 259d |  |
| 23 | 1.18 | 屋面施工 |  | 50d | 2005-06-13 | 2005-08-01 | 14 | 115d |  |
| 24 | 1.19 | 幕墙外窗施工 |  | 50d | 2005-06-13 | 2005-08-01 | 14 | 60d | 0d |
| 25 | 1.24 | 外墙涂料 |  | 15d | 2005-08-02 | 2005-08-16 | 24 | 65d | 5d |
| 26 | 1.21 | 风机安装 |  | 15d | 2005-06-13 | 2005-06-27 | 14 | 156d |  |
| 27 | 1.22 | 防雷接地、电管敷设 |  | 125d | 2005-01-27 | 2005-05-31 | 9SS | 98d | 0d |
| 28 | 1.23 | 穿线、穿缆、电机检查、接线 |  | 80d | 2005-04-12 | 2005-06-30 | 27FS-50d | 98d | 0d |
| 29 | 1.24 | 给排水立管、水平干管安装 |  | 30d | 2005-04-21 | 2005-05-20 | 11 | 141d | 0d |
| 30 | 1.25 | 设备安装 |  | 50d | 2005-05-21 | 2005-07-09 | 29 | 141d | 58d |
| 31 | 1.26 | 配电箱柜安装 |  | 20d | 2005-07-01 | 2005-07-20 | 28 | 98d | 0d |
| 32 | 1.27 | 灯具、插座安装 |  | 25d | 2005-07-21 | 2005-08-14 | 31 | 98d | 32d |
| 33 | 1.28 | 弱电施工 |  | 30d | 2005-07-16 | 2005-08-14 | 27FS+45d | 108d |  |
| 34 | 1.29 | 卫生间防水及瓷砖 |  | 30d | 2005-07-13 | 2005-08-11 | 17 | 83d | 0d |
| 35 | 1.30 | 卫生洁具安装 |  | 20d | 2005-08-17 | 2005-09-05 | 29, 34FS+5d | 83d | 0d |
| 36 | 1.31 | 电梯安装 |  | 30d | 2005-05-06 | 2005-06-04 | 11FS+15d | 166d | 0d |
| 37 | 1.32 | 电梯调试运行 |  | 3d | 2005-06-05 | 2005-06-07 | 36 | 166d | 0d |
| 38 | 1.33 | 墙顶刮腻子 |  | 20d | 2005-08-07 | 2005-08-26 | 18 | 0d |  |
| 39 | 1.35 | 室内油漆涂料施工 |  | 30d | 2005-08-27 | 2005-09-25 | 38 | 0d |  |
| 40 | 1.36 | 体育设施 |  | 60d | 2005-09-26 | 2005-11-24 | 39 | 0d |  |
| 41 | 1.34 | 电梯门套 |  | 10d | 2005-06-08 | 2005-06-17 | 37 | 166d |  |
| 42 | 1.37 | 灯具安装与调试 |  | 7d | 2005-09-16 | 2005-09-22 | 32, 39FS-10d | 66d | 0d |
| 43 | 1.38 | 电气系统调试 |  | 3d | 2005-09-23 | 2005-09-25 | 42 | 66d |  |
| 44 | 1.39 | 水系统调试 |  | 3d | 2005-09-06 | 2005-09-08 | 35, 30 | 83d |  |
| 45 | 1.40 | 局部平屋面施工 |  | 10d | 2005-06-13 | 2005-06-22 | 14 | 161d |  |
| 46 | 1.41 | 室外工程 |  | 35d | 2005-08-22 | 2005-09-25 | 24FS+20d, 25 | 60d |  |
| 47 | 1.42 | 内外檐清理 |  | 6d | 2005-11-25 | 2005-11-30 | 39, 46, 23, 24, 15, 40 | 0d |  |
| 48 | 1.43 | 竣工 | milestone | 0d | 2005-11-30 | 2005-11-30 | 43, 47, 41, 44, 22 | 0d |  |
